# Ejemplo de Plan de Trabajo de Proyecto de Edificación

Schedule from MS Project, 2011-02-25 to 2014-02-14.

## Calendars

- Standard: Mon-Fri 08:00-12:00, 13:00-17:00; Sat-Sun off.

## Schedule

| ID | WBS | Task | Duration | Start | Finish | Predecessors | Total slack | Free slack | Constraint |
| --- | --- | --- | --- | --- | --- | --- | --- | --- | --- |
| 1 | 1 | **Proyecto de Edificación de Clase Media de 8000m2** | 776d? | 2011-02-25 | 2014-02-14 |  | 0d |  |  |
| 2 | 1.1 | **Gastos Generales** | 120d | 2011-02-25 | 2011-08-11 |  | 566d |  |  |
| 3 | 1.1.1 | Proyecto de Arquitectura y demás disciplinas | 120d | 2011-02-25 | 2011-08-11 |  | 566d | 0d | start no earlier than 2011-02-25 |
| 4 | 1.2 | **Contratos por Actividad macro** | 656d? | 2011-08-12 | 2014-02-14 |  | 0d |  |  |
| 5 | 1.2.1 | Obras Preliminares | 15d | 2011-08-12 | 2011-09-01 | 3 | 566d | 0d |  |
| 6 | 1.2.2 | Movimiento de Tierra y Urbanismo | 30d | 2011-09-02 | 2011-10-13 | 3, 5 | 566d | 0d |  |
| 7 | 1.2.3 | **Estructura** | 315d? | 2011-10-14 | 2012-12-27 |  | 296d |  |  |
| 8 | 1.2.3.1 | Fundaciones | 45d? | 2011-10-14 | 2011-12-15 | 6 | 566d |  | finish no earlier than 2011-12-15 |
| 9 | 1.2.3.2 | Estructura de la edificación | 259d | 2012-01-02 | 2012-12-27 |  | 296d |  | finish no earlier than 2012-12-27 |
| 10 | 1.2.4 | Instalaciones Sanitarias y Especiales | 540d | 2012-01-09 | 2014-01-31 |  | 10d |  | start no earlier than 2012-01-09 |
| 11 | 1.2.5 | Instalaciones Eléctricas | 540d | 2012-01-09 | 2014-01-31 |  | 10d |  | start no earlier than 2012-01-09 |
| 12 | 1.2.6 | Instalaciones contra Incendios | 30d | 2013-09-30 | 2013-11-08 |  | 70d |  | start no earlier than 2013-09-30 |
| 13 | 1.2.7 | Albañilería | 360d | 2012-07-30 | 2013-12-13 |  | 45d |  | start no earlier than 2012-07-30 |
| 14 | 1.2.8 | Herrería | 160d | 2013-04-08 | 2013-11-15 |  | 65d |  | start no earlier than 2013-04-08 |
| 15 | 1.2.9 | Vidrios y Aluminios | 180d | 2013-05-27 | 2014-01-31 |  | 10d |  | start no earlier than 2013-05-27 |
| 16 | 1.2.10 | Ascensores | 360d | 2012-08-13 | 2013-12-27 |  | 35d |  | start no earlier than 2012-08-13 |
| 17 | 1.2.11 | Acabados con Pinturas | 150d | 2013-07-08 | 2014-01-31 |  | 10d |  | start no earlier than 2013-07-08 |
| 18 | 1.2.12 | Impermeablización | 60d | 2012-12-31 | 2013-03-22 |  | 235d |  | start no earlier than 2012-12-31 |
| 19 | 1.2.13 | Obras de Servicio y Varios | 30d | 2014-01-06 | 2014-02-14 |  | 0d |  | start no earlier than 2014-01-06 |
| 20 | 1.2.14 | Acabados Finales | 30d | 2014-01-06 | 2014-02-14 |  | 0d |  | start no earlier than 2014-01-06 |

Notes:
- 7: Las fundaciones se iniciarán para el mes de Octubre del 2011 y su plazo de ejecución será hasta Diciembre de 2011. / Finalizado las Fundaciones comienza la estructura del edificio desde mes de Enero de 2012 a Diciembre de 2012.
